# Office Renovation

Schedule from MS Project, 2022-04-04 to 2022-06-10, 7 hours a day, costs in $.

## Calendars

- Standard: Mon-Fri 09:00-12:00, 13:00-17:00; Sat-Sun off.
- Weekend work: Mon-Fri off; Sat-Sun 09:00-12:00, 13:00-17:00.

## Resources

| Resource | Rate | Cost per use |
| --- | --- | --- |
| Admin Assistant | 95 |  |
| Carpenter | 120 |  |
| Carpet Contractor |  |  |
| Fit-out Consultant | 175 | 50 |
| IT Consultant | 110 |  |
| Labourer | 95 |  |
| Management | 250 |  |
| Painter | 120 |  |
| Plastering Contractor | 120 |  |
| Project Manager | 155 |  |
| Staff | 120 |  |
| Cleaner | 95 |  |

## Schedule

| ID | WBS | Task | Type | Duration | Start | Finish | Predecessors | Total slack | Free slack | Deadline | Resources | Work | Cost |
| --- | --- | --- | --- | --- | --- | --- | --- | --- | --- | --- | --- | --- | --- |
| 1 | 1 | **Planning & Research** |  | 14d | 2022-04-04 | 2022-04-21 |  | 3d |  |  |  | 63h | 9,765 |
| 2 | 1.1 | Develop Requirements Documentation |  | 1d | 2022-04-04 | 2022-04-04 |  | 3d | 0d | 2022-04-15 | Project Manager | 7h | 1,085 |
| 3 | 1.2 | Fit-Out Consultant Research & Engagement |  | 2d | 2022-04-05 | 2022-04-06 | 2 | 3d | 0d |  | Project Manager | 14h | 2,170 |
| 4 | 1.3 | IT Network Contractor Research & Engagement |  | 2d | 2022-04-07 | 2022-04-08 | 3 | 3d | 0d |  | Project Manager | 14h | 2,170 |
| 5 | 1.4 | Building Contractor Research & Engagement |  | 2d | 2022-04-11 | 2022-04-12 | 4 | 3d | 0d |  | Project Manager | 14h | 2,170 |
| 6 | 1.5 | Submit Requirements to Resources & Request Quotes |  | 1d | 2022-04-13 | 2022-04-13 | 5 | 3d | 0d |  | Project Manager | 7h | 1,085 |
| 7 | 1.6 | Quotes Received |  | 1d | 2022-04-21 | 2022-04-21 | 6FS+5d | 3d | 0d |  | Project Manager | 7h | 1,085 |
| 8 | 1.7 | Planning & Research Complete | milestone | 0d | 2022-04-21 | 2022-04-21 | 7 | 3d | 0d |  |  |  |  |
| 9 | 2 | **Management Approval** |  | 5d | 2022-04-22 | 2022-04-28 |  | 3d |  |  |  | 42h | 7,175 |
| 10 | 2.1 | Consolidate Quotes and develop proposal |  | 2d | 2022-04-22 | 2022-04-25 | 8 | 3d | 0d |  | Project Manager | 14h | 2,170 |
| 11 | 2.2 | Develop Project Plan & Durations |  | 2d | 2022-04-26 | 2022-04-27 | 10 | 3d | 0d |  | Project Manager | 14h | 2,170 |
| 12 | 2.3 | Submit Project Plan & Costs to Management |  | 1d | 2022-04-28 | 2022-04-28 | 11 | 3d | 0d |  | Management; Project Manager | 14h | 2,835 |
| 13 | 2.4 | Management Approval Received | milestone | 0d | 2022-04-28 | 2022-04-28 | 12 | 3d | 0d |  |  |  |  |
| 14 | 3 | **Refit Office** |  | 26d | 2022-04-29 | 2022-06-05 |  | 0d |  |  |  | 259h | 38,447.5 |
| 15 | 3.1 | Appoint Resources |  | 1d | 2022-04-29 | 2022-04-29 | 13 | 3d | 0d |  | Project Manager | 7h | 1,085 |
| 16 | 3.2 | Staff Briefing |  | 1d | 2022-05-02 | 2022-05-02 | 15 | 3d | 0d |  | Project Manager; Staff [700%] | 56h | 6,965 |
| 17 | 3.3 | **Fit-Out Consultations** |  | 5d | 2022-05-03 | 2022-05-09 |  | 3d |  |  |  | 70h | 11,800 |
| 18 | 3.3.1 | Design office space/structure plan |  | 1d | 2022-05-03 | 2022-05-03 | 16 | 3d | 0d |  | Fit-out Consultant; Project Manager | 14h | 2,360 |
| 19 | 3.3.2 | Select & Order Carpet |  | 1d | 2022-05-04 | 2022-05-04 | 18 | 15d | 0d |  | Fit-out Consultant; Project Manager | 14h | 2,360 |
| 20 | 3.3.3 | Select & Order Paint |  | 1d | 2022-05-05 | 2022-05-05 | 19 | 15d | 0d |  | Fit-out Consultant; Project Manager | 14h | 2,360 |
| 21 | 3.3.4 | Select & Order Office Furniture |  | 1d | 2022-05-06 | 2022-05-06 | 20 | 15d | 0d |  | Fit-out Consultant; Project Manager | 14h | 2,360 |
| 22 | 3.3.5 | Select & Order digital PBX |  | 1d | 2022-05-09 | 2022-05-09 | 21 | 19d | 14d |  | Fit-out Consultant; Project Manager | 14h | 2,360 |
| 23 | 3.4 | **IT consultations** |  | 11d | 2022-05-03 | 2022-05-17 |  | 3d |  |  |  | 28h | 3,237.5 |
| 24 | 3.4.1 | Design IT network and phone points map |  | 1d | 2022-05-03 | 2022-05-03 | 16 | 3d | 0d |  | IT Consultant | 7h | 770 |
| 25 | 3.4.2 | Select & Order New PCs |  | 1d | 2022-05-04 | 2022-05-04 | 24 | 12d | 1d |  | IT Consultant | 7h | 770 |
| 26 | 3.4.3 | New PCs Arrive |  | 0.5d | 2022-05-16 | 2022-05-16 | 25FS+10ed | 13d | 0d |  | Project Manager | 3.5h | 542.5 |
| 27 | 3.4.4 | Configure SOE on PCs |  | 1.5d | 2022-05-16 | 2022-05-17 | 26 | 13d |  |  | IT Consultant | 10.5h | 1,155 |

| ID | WBS | Task | Type | Duration | Start | Finish | Predecessors | Total slack | Calendar | Resources | Work | Cost |
| --- | --- | --- | --- | --- | --- | --- | --- | --- | --- | --- | --- | --- |
| 28 | 3.5 | **Refit Office** |  | 20d | 2022-05-07 | 2022-06-05 |  | 0d |  |  | 98h | 15,360 |
| 29 | 3.5.1 | Erect New Walls |  | 2d | 2022-05-07 | 2022-05-08 | 18, 24 | 0d | Weekend work | Carpenter [200%] | 28h | 3,360 |
| 30 | 3.5.2 | Gyprock, Plaster & Finish |  | 2d | 2022-05-08 | 2022-05-14 | 29FS-1d | 0d | Weekend work | Plastering Contractor | 14h | 1,680 |
| 31 | 3.5.3 | Install Network & Phone Points |  | 1d | 2022-05-15 | 2022-05-15 | 30 | 0d | Weekend work | IT Consultant | 7h | 770 |
| 32 | 3.5.4 | Painting |  | 2d | 2022-05-21 | 2022-05-22 | 31 | 0d | Weekend work | Painter | 14h | 1,680 |
| 33 | 3.5.5 | Lay new carpets |  | 1d | 2022-05-28 | 2022-05-28 | 32 | 0d | Weekend work | Carpet Contractor | 7h | 5,000 |
| 34 | 3.5.6 | Install PBX hardware |  | 1d | 2022-05-29 | 2022-05-29 | 22, 33 | 1d | Weekend work | IT Consultant | 7h | 770 |
| 35 | 3.5.7 | Install New Furniture |  | 2d | 2022-05-29 | 2022-06-04 | 21, 33 | 0d | Weekend work | Labourer | 14h | 1,330 |
| 36 | 3.5.8 | Connect and install PCs and phones |  | 1d | 2022-06-05 | 2022-06-05 | 27, 34, 35 | 0d | Weekend work | IT Consultant | 7h | 770 |
| 37 | 3.5.9 | Refit Office Complete | milestone | 0d | 2022-06-05 | 2022-06-05 | 36 | 0d |  |  |  |  |
| 38 | 4 | **Office Move** |  | 29d | 2022-05-03 | 2022-06-10 |  | 0d |  |  | 472.5h | 55,807.5 |
| 39 | 4.1 | Order packing boxes |  | 0.5d | 2022-05-03 | 2022-05-03 | 16 | 23.5d |  | Admin Assistant | 3.5h | 332.5 |
| 40 | 4.2 | Staff Pack |  | 1d | 2022-06-06 | 2022-06-06 | 37, 39 | 0d |  | Project Manager; Staff [2000%] | 147h | 17,885 |
| 41 | 4.3 | Staff Move |  | 2d | 2022-06-07 | 2022-06-08 | 40 | 0d |  | Staff [2000%]; Labourer | 294h | 34,930 |
| 42 | 4.4 | Office cleaning |  | 2d | 2022-06-09 | 2022-06-10 | 41 | 0d |  | Cleaner [200%] | 28h | 2,660 |
| 43 | 4.5 | Office Move Complete | milestone | 0d | 2022-06-10 | 2022-06-10 | 42 | 0d |  |  |  |  |
