# Office Renovation

Schedule from MS Project, 2022-04-04 to 2022-05-25, 7 hours a day.

## Calendars

- Standard: Mon-Fri 09:00-12:00, 13:00-17:00; Sat-Sun off.

## Schedule

| ID | WBS | Task | Type | Duration | Start | Finish | Predecessors | Total slack | Free slack |
| --- | --- | --- | --- | --- | --- | --- | --- | --- | --- |
| 1 | 1 | **Planning & Research** |  | 14d | 2022-04-04 | 2022-04-21 |  | 1d |  |
| 2 | 1.1 | Develop Requirements Documentation |  | 1d | 2022-04-04 | 2022-04-04 |  | 1d | 0d |
| 3 | 1.2 | Fit-Out Consultant Research & Engagement |  | 2d | 2022-04-05 | 2022-04-06 | 2 | 1d | 0d |
| 4 | 1.3 | IT Network Contractor Research & Engagement |  | 2d | 2022-04-07 | 2022-04-08 | 3 | 1d | 0d |
| 5 | 1.4 | Building Contractor Research & Engagement |  | 2d | 2022-04-11 | 2022-04-12 | 4 | 1d | 0d |
| 6 | 1.5 | Submit Requirements to Resources & Request Quotes |  | 1d | 2022-04-13 | 2022-04-13 | 5 | 1d | 0d |
| 7 | 1.6 | Quotes Received |  | 1d | 2022-04-21 | 2022-04-21 | 6FS+5d | 1d | 0d |
| 8 | 1.7 | Planning & Research Complete | milestone | 0d | 2022-04-21 | 2022-04-21 | 7 | 1d | 0d |
| 9 | 2 | **Management Approval** |  | 5d | 2022-04-22 | 2022-04-28 |  | 1d |  |
| 10 | 2.1 | Consolidate Quotes and develop proposal |  | 2d | 2022-04-22 | 2022-04-25 | 8 | 1d | 0d |
| 11 | 2.2 | Develop Project Plan & Durations |  | 2d | 2022-04-26 | 2022-04-27 | 10 | 1d | 0d |
| 12 | 2.3 | Submit Project Plan & Costs to Management |  | 1d | 2022-04-28 | 2022-04-28 | 11 | 1d | 0d |
| 13 | 2.4 | Management Approval Received | milestone | 0d | 2022-04-28 | 2022-04-28 | 12 | 1d | 0d |
| 14 | 3 | **Refit Office** |  | 14d | 2022-04-29 | 2022-05-18 |  | 0d |  |
| 15 | 3.1 | Appoint Resources |  | 1d | 2022-04-29 | 2022-04-29 | 13 | 1d | 0d |
| 16 | 3.2 | Staff Briefing |  | 1d | 2022-05-02 | 2022-05-02 | 15 | 1d | 0d |
| 17 | 3.3 | **Fit-Out Consultations** |  | 4d | 2022-05-03 | 2022-05-06 |  | 1d |  |
| 18 | 3.3.1 | Design office space/structure plan |  | 1d | 2022-05-03 | 2022-05-03 | 16 | 1d | 0d |
| 19 | 3.3.2 | Select & Order Carpet |  | 1d | 2022-05-04 | 2022-05-04 | 18 | 6d | 0d |
| 20 | 3.3.3 | Select & Order Paint |  | 1d | 2022-05-04 | 2022-05-04 | 19SS | 6d | 0d |
| 21 | 3.3.4 | Select & Order Office Furniture |  | 1d | 2022-05-05 | 2022-05-05 | 20 | 6d | 0d |
| 22 | 3.3.5 | Select & Order digital PBX |  | 1d | 2022-05-06 | 2022-05-06 | 21 | 6d | 4d |
| 23 | 3.4 | **IT consultations** |  | 11d | 2022-05-03 | 2022-05-17 |  | 0d |  |
| 24 | 3.4.1 | Design IT network and phone points map |  | 1d | 2022-05-03 | 2022-05-03 | 16 | 1d | 0d |
| 25 | 3.4.2 | Select & Order New PCs |  | 1d | 2022-05-04 | 2022-05-04 | 24 | 1d |  |
| 26 | 3.4.3 | New PCs Arrive |  | 0.5d | 2022-05-16 | 2022-05-16 | 25FS+10ed | 0d |  |
| 27 | 3.4.4 | Configure SOE on PCs |  | 1.5d | 2022-05-16 | 2022-05-17 | 26 | 0d |  |

| ID | WBS | Task | Type | Duration | Start | Finish | Predecessors | Total slack | Free slack |
| --- | --- | --- | --- | --- | --- | --- | --- | --- | --- |
| 28 | 3.5 | **Refit Office** |  | 11d | 2022-05-04 | 2022-05-18 |  | 0d |  |
| 29 | 3.5.1 | Erect New Walls |  | 2d | 2022-05-04 | 2022-05-05 | 18, 24 | 1d | 0d |
| 30 | 3.5.2 | Gyprock, Plaster & Finish |  | 2d | 2022-05-05 | 2022-05-06 | 29FS-1d | 1d | 0d |
| 31 | 3.5.3 | Install Network & Phone Points |  | 1d | 2022-05-09 | 2022-05-09 | 30 | 1d | 0d |
| 32 | 3.5.4 | Painting |  | 2d | 2022-05-10 | 2022-05-11 | 31 | 1d | 0d |
| 33 | 3.5.5 | Lay new carpets |  | 1d | 2022-05-12 | 2022-05-12 | 32 | 1d | 0d |
| 34 | 3.5.6 | Install PBX hardware |  | 1d | 2022-05-13 | 2022-05-13 | 22, 33 | 2d |  |
| 35 | 3.5.7 | Install New Furniture |  | 2d | 2022-05-13 | 2022-05-16 | 21, 33 | 1d |  |
| 36 | 3.5.8 | Connect and install PCs and phones |  | 1d | 2022-05-18 | 2022-05-18 | 27, 34, 35 | 0d |  |
| 37 | 3.5.9 | Refit Office Complete | milestone | 0d | 2022-05-18 | 2022-05-18 | 36 | 0d |  |
| 38 | 4 | **Office Move** |  | 17d | 2022-05-03 | 2022-05-25 |  | 0d |  |
| 39 | 4.1 | Order packing boxes |  | 0.5d | 2022-05-03 | 2022-05-03 | 16 | 11.5d |  |
| 40 | 4.2 | Staff Pack |  | 1d | 2022-05-19 | 2022-05-19 | 37, 39 | 0d |  |
| 41 | 4.3 | Staff Move |  | 2d | 2022-05-20 | 2022-05-23 | 40 | 0d |  |
| 42 | 4.4 | Office cleaning |  | 2d | 2022-05-24 | 2022-05-25 | 41 | 0d |  |
| 43 | 4.5 | Office Move Complete | milestone | 0d | 2022-05-25 | 2022-05-25 | 42 | 0d |  |
