# Office Renovation

Schedule from MS Project, 2022-04-04 to 2022-06-10, 7 hours a day.

## Calendars

- Standard: Mon-Fri 09:00-12:00, 13:00-17:00; Sat-Sun off.
- Weekend work: Mon-Fri off; Sat-Sun 09:00-12:00, 13:00-17:00.

## Schedule

| ID | WBS | Task | Type | Duration | Start | Finish | Predecessors | Total slack | Free slack | Deadline |
| --- | --- | --- | --- | --- | --- | --- | --- | --- | --- | --- |
| 1 | 1 | **Planning & Research** |  | 14d | 2022-04-04 | 2022-04-21 |  | 3d |  |  |
| 2 | 1.1 | Develop Requirements Documentation |  | 1d | 2022-04-04 | 2022-04-04 |  | 3d | 0d | 2022-04-15 |
| 3 | 1.2 | Fit-Out Consultant Research & Engagement |  | 2d | 2022-04-05 | 2022-04-06 | 2 | 3d | 0d |  |
| 4 | 1.3 | IT Network Contractor Research & Engagement |  | 2d | 2022-04-07 | 2022-04-08 | 3 | 3d | 0d |  |
| 5 | 1.4 | Building Contractor Research & Engagement |  | 2d | 2022-04-11 | 2022-04-12 | 4 | 3d | 0d |  |
| 6 | 1.5 | Submit Requirements to Resources & Request Quotes |  | 1d | 2022-04-13 | 2022-04-13 | 5 | 3d | 0d |  |
| 7 | 1.6 | Quotes Received |  | 1d | 2022-04-21 | 2022-04-21 | 6FS+5d | 3d | 0d |  |
| 8 | 1.7 | Planning & Research Complete | milestone | 0d | 2022-04-21 | 2022-04-21 | 7 | 3d | 0d |  |
| 9 | 2 | **Management Approval** |  | 5d | 2022-04-22 | 2022-04-28 |  | 3d |  |  |
| 10 | 2.1 | Consolidate Quotes and develop proposal |  | 2d | 2022-04-22 | 2022-04-25 | 8 | 3d | 0d |  |
| 11 | 2.2 | Develop Project Plan & Durations |  | 2d | 2022-04-26 | 2022-04-27 | 10 | 3d | 0d |  |
| 12 | 2.3 | Submit Project Plan & Costs to Management |  | 1d | 2022-04-28 | 2022-04-28 | 11 | 3d | 0d |  |
| 13 | 2.4 | Management Approval Received | milestone | 0d | 2022-04-28 | 2022-04-28 | 12 | 3d | 0d |  |
| 14 | 3 | **Refit Office** |  | 26d | 2022-04-29 | 2022-06-05 |  | 0d |  |  |
| 15 | 3.1 | Appoint Resources |  | 1d | 2022-04-29 | 2022-04-29 | 13 | 3d | 0d |  |
| 16 | 3.2 | Staff Briefing |  | 1d | 2022-05-02 | 2022-05-02 | 15 | 3d | 0d |  |
| 17 | 3.3 | **Fit-Out Consultations** |  | 4d | 2022-05-03 | 2022-05-06 |  | 3d |  |  |
| 18 | 3.3.1 | Design office space/structure plan |  | 1d | 2022-05-03 | 2022-05-03 | 16 | 3d | 0d |  |
| 19 | 3.3.2 | Select & Order Carpet |  | 1d | 2022-05-04 | 2022-05-04 | 18 | 16d | 0d |  |
| 20 | 3.3.3 | Select & Order Paint |  | 1d | 2022-05-04 | 2022-05-04 | 19SS | 16d | 0d |  |
| 21 | 3.3.4 | Select & Order Office Furniture |  | 1d | 2022-05-05 | 2022-05-05 | 20 | 16d | 0d |  |
| 22 | 3.3.5 | Select & Order digital PBX |  | 1d | 2022-05-06 | 2022-05-06 | 21 | 20d | 15d |  |
| 23 | 3.4 | **IT consultations** |  | 11d | 2022-05-03 | 2022-05-17 |  | 3d |  |  |
| 24 | 3.4.1 | Design IT network and phone points map |  | 1d | 2022-05-03 | 2022-05-03 | 16 | 3d | 0d |  |
| 25 | 3.4.2 | Select & Order New PCs |  | 1d | 2022-05-04 | 2022-05-04 | 24 | 12d | 1d |  |
| 26 | 3.4.3 | New PCs Arrive |  | 0.5d | 2022-05-16 | 2022-05-16 | 25FS+10ed | 13d | 0d |  |
| 27 | 3.4.4 | Configure SOE on PCs |  | 1.5d | 2022-05-16 | 2022-05-17 | 26 | 13d |  |  |

| ID | WBS | Task | Type | Duration | Start | Finish | Predecessors | Total slack | Calendar |
| --- | --- | --- | --- | --- | --- | --- | --- | --- | --- |
| 28 | 3.5 | **Refit Office** |  | 20d | 2022-05-07 | 2022-06-05 |  | 0d |  |
| 29 | 3.5.1 | Erect New Walls |  | 2d | 2022-05-07 | 2022-05-08 | 18, 24 | 0d | Weekend work |
| 30 | 3.5.2 | Gyprock, Plaster & Finish |  | 2d | 2022-05-08 | 2022-05-14 | 29FS-1d | 0d | Weekend work |
| 31 | 3.5.3 | Install Network & Phone Points |  | 1d | 2022-05-15 | 2022-05-15 | 30 | 0d | Weekend work |
| 32 | 3.5.4 | Painting |  | 2d | 2022-05-21 | 2022-05-22 | 31 | 0d | Weekend work |
| 33 | 3.5.5 | Lay new carpets |  | 1d | 2022-05-28 | 2022-05-28 | 32 | 0d | Weekend work |
| 34 | 3.5.6 | Install PBX hardware |  | 1d | 2022-05-29 | 2022-05-29 | 22, 33 | 1d | Weekend work |
| 35 | 3.5.7 | Install New Furniture |  | 2d | 2022-05-29 | 2022-06-04 | 21, 33 | 0d | Weekend work |
| 36 | 3.5.8 | Connect and install PCs and phones |  | 1d | 2022-06-05 | 2022-06-05 | 27, 34, 35 | 0d | Weekend work |
| 37 | 3.5.9 | Refit Office Complete | milestone | 0d | 2022-06-05 | 2022-06-05 | 36 | 0d |  |
| 38 | 4 | **Office Move** |  | 29d | 2022-05-03 | 2022-06-10 |  | 0d |  |
| 39 | 4.1 | Order packing boxes |  | 0.5d | 2022-05-03 | 2022-05-03 | 16 | 23.5d |  |
| 40 | 4.2 | Staff Pack |  | 1d | 2022-06-06 | 2022-06-06 | 37, 39 | 0d |  |
| 41 | 4.3 | Staff Move |  | 2d | 2022-06-07 | 2022-06-08 | 40 | 0d |  |
| 42 | 4.4 | Office cleaning |  | 2d | 2022-06-09 | 2022-06-10 | 41 | 0d |  |
| 43 | 4.5 | Office Move Complete | milestone | 0d | 2022-06-10 | 2022-06-10 | 42 | 0d |  |
