# Office Renovation

Schedule from MS Project, 2022-04-04 to 2022-06-10, 7 hours a day.

## Calendars

- Standard: Mon-Fri 09:00-12:00, 13:00-17:00; Sat-Sun off.
- Weekend work: Mon-Fri off; Sat-Sun 09:00-12:00, 13:00-17:00.

## Resources

| Resource |
| --- |
| Admin Assistant |
| Carpenter |
| Carpet Contractor |
| Fit-out Consultant |
| IT Consultant |
| Labourer |
| Management |
| Painter |
| Plastering Contractor |
| Project Manager |
| Staff |
| Cleaner |

## Schedule

| ID | WBS | Task | Type | Duration | Start | Finish | Predecessors | Total slack | Free slack | Deadline | Resources | Work |
| --- | --- | --- | --- | --- | --- | --- | --- | --- | --- | --- | --- | --- |
| 1 | 1 | **Planning & Research** |  | 14d | 2022-04-04 | 2022-04-21 |  | 3d |  |  |  | 63h |
| 2 | 1.1 | Develop Requirements Documentation |  | 1d | 2022-04-04 | 2022-04-04 |  | 3d | 0d | 2022-04-15 | Project Manager | 7h |
| 3 | 1.2 | Fit-Out Consultant Research & Engagement |  | 2d | 2022-04-05 | 2022-04-06 | 2 | 3d | 0d |  | Project Manager | 14h |
| 4 | 1.3 | IT Network Contractor Research & Engagement |  | 2d | 2022-04-07 | 2022-04-08 | 3 | 3d | 0d |  | Project Manager | 14h |
| 5 | 1.4 | Building Contractor Research & Engagement |  | 2d | 2022-04-11 | 2022-04-12 | 4 | 3d | 0d |  | Project Manager | 14h |
| 6 | 1.5 | Submit Requirements to Resources & Request Quotes |  | 1d | 2022-04-13 | 2022-04-13 | 5 | 3d | 0d |  | Project Manager | 7h |
| 7 | 1.6 | Quotes Received |  | 1d | 2022-04-21 | 2022-04-21 | 6FS+5d | 3d | 0d |  | Project Manager | 7h |
| 8 | 1.7 | Planning & Research Complete | milestone | 0d | 2022-04-21 | 2022-04-21 | 7 | 3d | 0d |  |  |  |
| 9 | 2 | **Management Approval** |  | 5d | 2022-04-22 | 2022-04-28 |  | 3d |  |  |  | 42h |
| 10 | 2.1 | Consolidate Quotes and develop proposal |  | 2d | 2022-04-22 | 2022-04-25 | 8 | 3d | 0d |  | Project Manager | 14h |
| 11 | 2.2 | Develop Project Plan & Durations |  | 2d | 2022-04-26 | 2022-04-27 | 10 | 3d | 0d |  | Project Manager | 14h |
| 12 | 2.3 | Submit Project Plan & Costs to Management |  | 1d | 2022-04-28 | 2022-04-28 | 11 | 3d | 0d |  | Management; Project Manager | 14h |
| 13 | 2.4 | Management Approval Received | milestone | 0d | 2022-04-28 | 2022-04-28 | 12 | 3d | 0d |  |  |  |
| 14 | 3 | **Refit Office** |  | 26d | 2022-04-29 | 2022-06-05 |  | 0d |  |  |  | 266h |
| 15 | 3.1 | Appoint Resources |  | 1d | 2022-04-29 | 2022-04-29 | 13 | 3d | 0d |  | Project Manager | 7h |
| 16 | 3.2 | Staff Briefing |  | 1d | 2022-05-02 | 2022-05-02 | 15 | 3d | 0d |  | Project Manager; Staff [700%] | 56h |
| 17 | 3.3 | **Fit-Out Consultations** |  | 4d | 2022-05-03 | 2022-05-06 |  | 3d |  |  |  | 70h |
| 18 | 3.3.1 | Design office space/structure plan |  | 1d | 2022-05-03 | 2022-05-03 | 16 | 3d | 0d |  | Fit-out Consultant; Project Manager | 14h |
| 19 | 3.3.2 | Select & Order Carpet |  | 1d | 2022-05-04 | 2022-05-04 | 18 | 16d | 0d |  | Fit-out Consultant; Project Manager | 14h |
| 20 | 3.3.3 | Select & Order Paint |  | 1d | 2022-05-04 | 2022-05-04 | 19SS | 16d | 0d |  | Fit-out Consultant; Project Manager | 14h |
| 21 | 3.3.4 | Select & Order Office Furniture |  | 1d | 2022-05-05 | 2022-05-05 | 20 | 16d | 0d |  | Fit-out Consultant; Project Manager | 14h |
| 22 | 3.3.5 | Select & Order digital PBX |  | 1d | 2022-05-06 | 2022-05-06 | 21 | 20d | 15d |  | Fit-out Consultant; Project Manager | 14h |
| 23 | 3.4 | **IT consultations** |  | 11d | 2022-05-03 | 2022-05-17 |  | 3d |  |  |  | 35h |
| 24 | 3.4.1 | Design IT network and phone points map |  | 1d | 2022-05-03 | 2022-05-03 | 16 | 3d | 0d |  | IT Consultant; Project Manager | 14h |
| 25 | 3.4.2 | Select & Order New PCs |  | 1d | 2022-05-04 | 2022-05-04 | 24 | 12d | 1d |  | Project Manager | 7h |
| 26 | 3.4.3 | New PCs Arrive |  | 0.5d | 2022-05-16 | 2022-05-16 | 25FS+10ed | 13d | 0d |  | Project Manager | 3.5h |
| 27 | 3.4.4 | Configure SOE on PCs |  | 1.5d | 2022-05-16 | 2022-05-17 | 26 | 13d |  |  | IT Consultant | 10.5h |

| ID | WBS | Task | Type | Duration | Start | Finish | Predecessors | Total slack | Calendar | Resources | Work |
| --- | --- | --- | --- | --- | --- | --- | --- | --- | --- | --- | --- |
| 28 | 3.5 | **Refit Office** |  | 20d | 2022-05-07 | 2022-06-05 |  | 0d |  |  | 98h |
| 29 | 3.5.1 | Erect New Walls |  | 2d | 2022-05-07 | 2022-05-08 | 18, 24 | 0d | Weekend work | Carpenter [200%] | 28h |
| 30 | 3.5.2 | Gyprock, Plaster & Finish |  | 2d | 2022-05-08 | 2022-05-14 | 29FS-1d | 0d | Weekend work | Plastering Contractor | 14h |
| 31 | 3.5.3 | Install Network & Phone Points |  | 1d | 2022-05-15 | 2022-05-15 | 30 | 0d | Weekend work | IT Consultant | 7h |
| 32 | 3.5.4 | Painting |  | 2d | 2022-05-21 | 2022-05-22 | 31 | 0d | Weekend work | Painter | 14h |
| 33 | 3.5.5 | Lay new carpets |  | 1d | 2022-05-28 | 2022-05-28 | 32 | 0d | Weekend work | Carpet Contractor | 7h |
| 34 | 3.5.6 | Install PBX hardware |  | 1d | 2022-05-29 | 2022-05-29 | 22, 33 | 1d | Weekend work | IT Consultant | 7h |
| 35 | 3.5.7 | Install New Furniture |  | 2d | 2022-05-29 | 2022-06-04 | 21, 33 | 0d | Weekend work | Labourer | 14h |
| 36 | 3.5.8 | Connect and install PCs and phones |  | 1d | 2022-06-05 | 2022-06-05 | 27, 34, 35 | 0d | Weekend work | IT Consultant | 7h |
| 37 | 3.5.9 | Refit Office Complete | milestone | 0d | 2022-06-05 | 2022-06-05 | 36 | 0d |  |  |  |
| 38 | 4 | **Office Move** |  | 29d | 2022-05-03 | 2022-06-10 |  | 0d |  |  | 472.5h |
| 39 | 4.1 | Order packing boxes |  | 0.5d | 2022-05-03 | 2022-05-03 | 16 | 23.5d |  | Project Manager | 3.5h |
| 40 | 4.2 | Staff Pack |  | 1d | 2022-06-06 | 2022-06-06 | 37, 39 | 0d |  | Project Manager; Staff [2000%] | 147h |
| 41 | 4.3 | Staff Move |  | 2d | 2022-06-07 | 2022-06-08 | 40 | 0d |  | Staff [2000%]; Labourer | 294h |
| 42 | 4.4 | Office cleaning |  | 2d | 2022-06-09 | 2022-06-10 | 41 | 0d |  | Cleaner [200%] | 28h |
| 43 | 4.5 | Office Move Complete | milestone | 0d | 2022-06-10 | 2022-06-10 | 42 | 0d |  |  |  |
