# Office Renovation

Schedule from MS Project, 2022-04-04 to 2022-06-24, status date 2022-05-16, 7 hours a day, costs in $, A marks actual dates.

## Calendars

- Standard: Mon-Fri 09:00-12:00, 13:00-17:00; Sat-Sun off.
- Weekend work: Mon-Fri off; Sat-Sun 09:00-12:00, 13:00-17:00.

## Resources

| Resource | Rate | Cost per use |
| --- | --- | --- |
| Admin Assistant | 95 |  |
| Carpenter | 120 |  |
| Carpet Contractor |  |  |
| Fit-out Consultant | 175 | 50 |
| IT Consultant | 110 |  |
| Labourer | 95 |  |
| Management | 250 |  |
| Painter | 120 |  |
| Plastering Contractor | 120 |  |
| Project Manager | 155 |  |
| Staff | 120 |  |
| Cleaner | 95 |  |

## Schedule

| ID | WBS | Task | Type | Duration | Start | Finish | Predecessors | Complete | Baseline start | Baseline finish | Baseline duration | Total slack | Free slack | Deadline | Resources | Work | Actual work | Cost | Baseline cost | Actual cost |
| --- | --- | --- | --- | --- | --- | --- | --- | --- | --- | --- | --- | --- | --- | --- | --- | --- | --- | --- | --- | --- |
| 1 | 1 | **Planning & Research** |  | 16d | 2022-04-04 A | 2022-04-26 A |  | 100% | 2022-04-04 | 2022-04-26 | 16d |  |  |  |  | 63h | 63h | 9,765 | 9,765 | 9,765 |
| 2 | 1.1 | Develop Requirements Documentation |  | 1d | 2022-04-04 A | 2022-04-04 A |  | 100% | 2022-04-04 | 2022-04-04 | 1d |  |  | 2022-04-15 | Project Manager | 7h | 7h | 1,085 | 1,085 | 1,085 |
| 3 | 1.2 | Fit-Out Consultant Research & Engagement |  | 2d | 2022-04-05 A | 2022-04-06 A | 2 | 100% | 2022-04-05 | 2022-04-06 | 2d |  |  |  | Project Manager | 14h | 14h | 2,170 | 2,170 | 2,170 |
| 4 | 1.3 | IT Network Contractor Research & Engagement |  | 2d | 2022-04-07 A | 2022-04-08 A | 3 | 100% | 2022-04-07 | 2022-04-08 | 2d |  |  |  | Project Manager | 14h | 14h | 2,170 | 2,170 | 2,170 |
| 5 | 1.4 | Building Contractor Research & Engagement |  | 2d | 2022-04-13 A | 2022-04-14 A | 4 | 100% | 2022-04-13 | 2022-04-14 | 2d |  |  |  | Project Manager | 14h | 14h | 2,170 | 2,170 | 2,170 |
| 6 | 1.5 | Submit Requirements to Resources & Request Quotes |  | 1d | 2022-04-15 A | 2022-04-15 A | 5 | 100% | 2022-04-15 | 2022-04-15 | 1d |  |  |  | Project Manager | 7h | 7h | 1,085 | 1,085 | 1,085 |
| 7 | 1.6 | Quotes Received |  | 1d | 2022-04-25 A | 2022-04-25 A | 6FS+5d | 100% | 2022-04-25 | 2022-04-25 | 1d |  |  |  | Project Manager | 7h | 7h | 1,085 | 1,085 | 1,085 |
| 8 | 1.7 | Planning & Research Complete | milestone | 0d | 2022-04-26 A | 2022-04-26 A | 7 | 100% | 2022-04-26 | 2022-04-26 | 0d |  |  |  |  |  |  |  |  |  |
| 9 | 2 | **Management Approval** |  | 10d | 2022-04-26 A | 2022-05-10 A |  | 100% | 2022-04-26 | 2022-05-10 | 10d |  |  |  |  | 42h | 42h | 7,175 | 7,175 | 7,175 |
| 10 | 2.1 | Consolidate Quotes and develop proposal |  | 2d | 2022-04-26 A | 2022-04-27 A | 8 | 100% | 2022-04-26 | 2022-04-27 | 2d |  |  |  | Project Manager | 14h | 14h | 2,170 | 2,170 | 2,170 |
| 11 | 2.2 | Develop Project Plan & Durations |  | 2d | 2022-04-28 A | 2022-04-29 A | 10 | 100% | 2022-04-28 | 2022-04-29 | 2d |  |  |  | Project Manager | 14h | 14h | 2,170 | 2,170 | 2,170 |
| 12 | 2.3 | Submit Project Plan & Costs to Management |  | 1d | 2022-05-03 A | 2022-05-03 A | 11 | 100% | 2022-05-03 | 2022-05-03 | 1d |  |  |  | Management; Project Manager | 14h | 14h | 2,835 | 2,835 | 2,835 |
| 13 | 2.4 | Management Approval Received | milestone | 0d | 2022-05-10 A | 2022-05-10 A | 12 | 100% | 2022-05-10 | 2022-05-10 | 0d |  |  |  |  |  |  |  |  |  |
| 14 | 3 | **Refit Office** |  | 29d | 2022-05-10 | 2022-06-18 |  |  | 2022-05-10 | 2022-06-18 | 29d | 0d |  |  |  | 245h |  | 36,942.5 | 36,942.5 |  |
| 15 | 3.1 | Appoint Resources |  | 1d | 2022-05-10 | 2022-05-10 | 13 |  | 2022-05-10 | 2022-05-10 | 1d | 1d | 0d |  | Project Manager | 7h |  | 1,085 | 1,085 |  |
| 16 | 3.2 | Staff Briefing |  | 1d | 2022-05-11 | 2022-05-11 | 15 |  | 2022-05-11 | 2022-05-11 | 1d | 1d | 0d |  | Project Manager; Staff [700%] | 56h |  | 6,965 | 6,965 |  |
| 17 | 3.3 | **Fit-Out Consultations** |  | 5d | 2022-05-12 | 2022-05-18 |  |  | 2022-05-12 | 2022-05-18 | 5d | 1d |  |  |  | 70h |  | 11,800 | 11,800 |  |
| 18 | 3.3.1 | Design office space/structure plan |  | 1d | 2022-05-12 | 2022-05-12 | 16 |  | 2022-05-12 | 2022-05-12 | 1d | 1d | 0d |  | Fit-out Consultant; Project Manager | 14h |  | 2,360 | 2,360 |  |
| 19 | 3.3.2 | Select & Order Carpet |  | 1d | 2022-05-13 | 2022-05-13 | 18 |  | 2022-05-13 | 2022-05-13 | 1d | 22d | 0d |  | Fit-out Consultant; Project Manager | 14h |  | 2,360 | 2,360 |  |
| 20 | 3.3.3 | Select & Order Paint |  | 1d | 2022-05-16 | 2022-05-16 | 19 |  | 2022-05-16 | 2022-05-16 | 1d | 22d | 0d |  | Fit-out Consultant; Project Manager | 14h |  | 2,360 | 2,360 |  |
| 21 | 3.3.4 | Select & Order Office Furniture |  | 1d | 2022-05-17 | 2022-05-17 | 20 |  | 2022-05-17 | 2022-05-17 | 1d | 22d | 0d |  | Fit-out Consultant; Project Manager | 14h |  | 2,360 | 2,360 |  |
| 22 | 3.3.5 | Select & Order digital PBX |  | 1d | 2022-05-18 | 2022-05-18 | 21 |  | 2022-05-18 | 2022-05-18 | 1d | 22d | 17d |  | Fit-out Consultant; Project Manager | 14h |  | 2,360 | 2,360 |  |
| 23 | 3.4 | **IT consultations** |  | 10d | 2022-05-12 | 2022-05-25 |  |  | 2022-05-12 | 2022-05-25 | 10d | 1d |  |  |  | 28h |  | 3,237.5 | 3,237.5 |  |
| 24 | 3.4.1 | Design IT network and phone points map |  | 1d | 2022-05-12 | 2022-05-12 | 16 |  | 2022-05-12 | 2022-05-12 | 1d | 1d | 0d |  | IT Consultant | 7h |  | 770 | 770 |  |
| 25 | 3.4.2 | Select & Order New PCs |  | 1d | 2022-05-13 | 2022-05-13 | 24 |  | 2022-05-13 | 2022-05-13 | 1d | 15d | 0d |  | IT Consultant | 7h |  | 770 | 770 |  |
| 26 | 3.4.3 | New PCs Arrive |  | 0.5d | 2022-05-24 | 2022-05-24 | 25FS+10ed |  | 2022-05-24 | 2022-05-24 | 0.5d | 17d | 0d |  | Project Manager | 3.5h |  | 542.5 | 542.5 |  |
| 27 | 3.4.4 | Configure SOE on PCs |  | 1.5d | 2022-05-24 | 2022-05-25 | 26 |  | 2022-05-24 | 2022-05-25 | 1.5d | 17d |  |  | IT Consultant | 10.5h |  | 1,155 | 1,155 |  |

| ID | WBS | Task | Type | Duration | Start | Finish | Predecessors | Baseline start | Baseline finish | Baseline duration | Total slack | Free slack | Calendar | Resources | Work | Cost | Baseline cost |
| --- | --- | --- | --- | --- | --- | --- | --- | --- | --- | --- | --- | --- | --- | --- | --- | --- | --- |
| 28 | 3.5 | **Refit Office** |  | 25d | 2022-05-14 | 2022-06-18 |  | 2022-05-14 | 2022-06-18 | 25d | 0d |  |  |  | 84h | 13,855 | 13,855 |
| 29 | 3.5.1 | Erect New Walls |  | 2d | 2022-05-14 | 2022-05-15 | 18, 24 | 2022-05-14 | 2022-05-15 | 2d | 1d | 0d | Weekend work | Carpenter [200%] | 28h | 3,360 | 3,360 |
| 30 | 3.5.2 | Variation #1 - Fit out and install new reception area |  | 2d | 2022-05-21 | 2022-05-22 | 29 | 2022-05-21 | 2022-05-22 | 2d | 1d | 0d | Weekend work |  |  |  |  |
| 31 | 3.5.3 | Gyprock, Plaster & Finish |  | 1d | 2022-05-28 | 2022-05-28 | 29FS-1d, 30 | 2022-05-28 | 2022-05-28 | 1d | 1d | 0d | Weekend work | Plastering Contractor | 7h | 840 | 840 |
| 32 | 3.5.4 | Install Network & Phone Points |  | 1d | 2022-05-29 | 2022-05-29 | 31 | 2022-05-29 | 2022-05-29 | 1d | 1d | 0d | Weekend work | IT Consultant | 7h | 770 | 770 |
| 33 | 3.5.5 | Painting |  | 2d | 2022-06-04 | 2022-06-05 | 32 | 2022-06-04 | 2022-06-05 | 2d | 1d | 0d | Weekend work | Painter | 14h | 1,680 | 1,680 |
| 34 | 3.5.6 | Lay new carpets |  | 1d | 2022-06-11 | 2022-06-11 | 33 | 2022-06-11 | 2022-06-11 | 1d | 1d | 0d | Weekend work | Carpet Contractor | 7h | 5,000 | 5,000 |
| 35 | 3.5.7 | Install PBX hardware |  | 1d | 2022-06-12 | 2022-06-12 | 22, 34 | 2022-06-12 | 2022-06-12 | 1d | 1d | 0d | Weekend work | IT Consultant | 7h | 770 | 770 |
| 36 | 3.5.8 | Install New Furniture |  | 1d | 2022-06-12 | 2022-06-12 | 21, 34 | 2022-06-12 | 2022-06-12 | 1d | 1d | 0d | Weekend work | Labourer | 7h | 665 | 665 |
| 37 | 3.5.9 | Connect and install PCs and phones |  | 1d | 2022-06-18 | 2022-06-18 | 27, 35, 36 | 2022-06-18 | 2022-06-18 | 1d | 1d | 0d | Weekend work | IT Consultant | 7h | 770 | 770 |
| 38 | 3.5.10 | Refit Office Complete | milestone | 0d | 2022-06-18 | 2022-06-18 | 37 | 2022-06-18 | 2022-06-18 | 0d | 0d |  |  |  |  |  |  |
| 39 | 4 | **Office Move** |  | 32d | 2022-05-12 | 2022-06-24 |  | 2022-05-12 | 2022-06-24 | 32d | 0d |  |  |  | 472.5h | 55,807.5 | 55,807.5 |
| 40 | 4.1 | Order packing boxes |  | 0.5d | 2022-05-12 | 2022-05-12 | 16 | 2022-05-12 | 2022-05-12 | 0.5d | 26.5d |  |  | Admin Assistant | 3.5h | 332.5 | 332.5 |
| 41 | 4.2 | Staff Pack |  | 1d | 2022-06-20 | 2022-06-20 | 38, 40 | 2022-06-20 | 2022-06-20 | 1d | 0d |  |  | Project Manager; Staff [2000%] | 147h | 17,885 | 17,885 |
| 42 | 4.3 | Staff Move |  | 2d | 2022-06-21 | 2022-06-22 | 41 | 2022-06-21 | 2022-06-22 | 2d | 0d |  |  | Staff [2000%]; Labourer | 294h | 34,930 | 34,930 |
| 43 | 4.4 | Office cleaning |  | 2d | 2022-06-23 | 2022-06-24 | 42 | 2022-06-23 | 2022-06-24 | 2d | 0d |  |  | Cleaner [200%] | 28h | 2,660 | 2,660 |
| 44 | 4.5 | Office Move Complete | milestone | 0d | 2022-06-24 | 2022-06-24 | 43 | 2022-06-24 | 2022-06-24 | 0d | 0d |  |  |  |  |  |  |
